# LACRAMARCA231001R8-2

Schedule from Primavera P6, 2023-11-01 to 2024-05-10, data date 2023-11-01.

## Calendars

- Angel: Mon-Sun 08:00-18:00.
- QSC: Mon-Sat 07:00-17:00; Sun off.

## Schedule

| ID | WBS | Activity | Type | Duration | Start | Finish | Predecessors | Total float | Free float | Constraint | Calendar | MSP Outline Number | MSP Unique ID | MSP Project Name | Imported Early Start | Imported Late Start | Imported Start | Imported Early Finish | Imported Late Finish | Imported Finish | MSP ID | MSP Task Order |
| --- | --- | --- | --- | --- | --- | --- | --- | --- | --- | --- | --- | --- | --- | --- | --- | --- | --- | --- | --- | --- | --- | --- |
|  | 0 | **HITOS** |  |  | 2023-11-01 | 2024-05-10 |  |  |  |  |  |  |  |  |  |  |  |  |  |  |  |  |
| 000002 |  | INICIO | milestone | 0d | 2023-11-01 | 2023-11-01 |  | 0d |  | start on or after 2023-11-01 |  | 1.1 | 624 | LACRAMARCA231001R8 | 2023-11-01 | 2023-11-01 | 2023-11-01 | 2023-10-31 | 2023-11-01 | 2023-11-01 | 2 | 2 |
| 000003 |  | KOM | milestone | 0d | 2023-11-02 | 2023-11-02 | 000002 FS+2d | 0d |  | start on or after 2022-10-04 |  | 1.2 | 1382 | LACRAMARCA231001R8 | 2023-11-04 | 2023-11-03 | 2023-11-03 | 2023-11-03 | 2023-11-03 | 2023-11-03 | 3 | 3 |
| 000004 |  | ENTREGA DE TERRENO | milestone | 0d | 2023-11-03 | 2023-11-03 | 000003 FS+1d | 0d |  | start on or after 2022-10-06 |  | 1.3 | 1383 | LACRAMARCA231001R8 | 2023-11-05 | 2023-11-04 | 2023-11-04 | 2023-11-04 | 2023-11-04 | 2023-11-04 | 4 | 4 |
| 000005 |  | NOTIFICACION DE OS | milestone | 0d | 2023-11-03 | 2023-11-03 | 000004 | 0d |  | start on or after 2022-10-07 |  | 1.4 | 1381 | LACRAMARCA231001R8 | 2023-11-05 | 2023-11-04 | 2023-11-04 | 2023-11-04 | 2023-11-04 | 2023-11-04 | 5 | 5 |
| 000006 |  | Inicio OS | milestone | 0d | 2023-11-03 | 2023-11-03 | 000005 | 0d |  | start on or after 2022-10-07 |  | 1.5 | 1380 | LACRAMARCA231001R8 | 2023-11-05 | 2023-11-04 | 2023-11-04 | 2023-11-04 | 2023-11-04 | 2023-11-04 | 6 | 6 |
| 000007 |  | Inicio del Proyecto | milestone | 0d | 2023-11-03 | 2023-11-03 | 000006 | 0d |  | start on or after 2017-07-01 |  | 1.6 | 218 | LACRAMARCA231001R8 | 2023-11-05 | 2023-11-04 | 2023-11-04 | 2023-11-04 | 2023-11-04 | 2023-11-04 | 7 | 7 |
| 000008 |  | Fin de la Construccion | milestone | 0d | 2024-05-10 | 2024-05-10 | 000264, 000018 | 0d |  |  |  | 1.7 | 625 | LACRAMARCA231001R8 | 2024-05-12 | 2024-05-11 | 2024-05-11 | 2024-05-11 | 2024-05-11 | 2024-05-11 | 8 | 8 |
|  | 1 | **DEFENSAS RIBEREÑAS** |  |  | 2023-11-04 | 2024-05-10 |  |  |  |  |  |  |  |  |  |  |  |  |  |  |  |  |
|  | 1 | **OBRAS PRELIMINARES** |  |  | 2023-11-14 | 2024-05-08 |  |  |  |  |  |  |  |  |  |  |  |  |  |  |  |  |
| 000012 |  | CARTEL DE IDENTIFICACIÓN OBRA 4.80 x 3.60 m. |  | 10d | 2023-11-14 | 2023-11-23 | 000016 SS+10d | 2d | 0d |  |  | 1.8.1.1.1 | 1072 | LACRAMARCA231001R8 | 2023-11-14 | 2023-11-14 | 2023-11-14 | 2023-11-24 | 2023-11-24 | 2023-11-24 | 12 | 12 |
| 000013 |  | INSTALACIONES PROVISIONALES PARA LA OBRA |  | 15d | 2023-11-14 | 2023-11-28 | 000012 SS | 2d | 0d |  |  | 1.8.1.1.2 | 1140 | LACRAMARCA231001R8 | 2023-11-14 | 2023-11-14 | 2023-11-14 | 2023-11-29 | 2023-11-29 | 2023-11-29 | 13 | 13 |
| 000014 |  | MANTENIMIENTO DE TRÁNSITO Y SEGURIDAD VIAL |  | 162d | 2023-11-29 | 2024-05-08 | 000013 | 2d |  |  |  | 1.8.1.1.3 | 1073 | LACRAMARCA231001R8 | 2023-11-29 | 2023-11-29 | 2023-11-29 | 2024-05-11 | 2024-05-11 | 2024-05-11 | 14 | 14 |
|  | 2 | **TRABAJOS PRELIMINARES** |  |  | 2023-11-04 | 2024-05-10 |  |  |  |  |  |  |  |  |  |  |  |  |  |  |  |  |
| 000016 |  | MOVILIZACION DE EQUIPOS |  | 20d | 2023-11-04 | 2023-11-23 | 000007 | 0d |  |  |  | 1.8.1.2.1 | 1909 | LACRAMARCA231001R8 | 2023-11-04 | 2023-11-04 | 2023-11-04 | 2023-11-24 | 2023-11-24 | 2023-11-24 | 16 | 16 |
| 000017 |  | TOPOGRAFÍA Y GEOREFERENCIACIÓN |  | 177d | 2023-11-14 | 2024-05-08 | 000016 FS-10d | 2d |  |  |  | 1.8.1.2.2 | 1910 | LACRAMARCA231001R8 | 2023-11-14 | 2023-11-14 | 2023-11-14 | 2024-05-11 | 2024-05-11 | 2024-05-11 | 17 | 17 |
| 000018 |  | DESMOVILIZACION DE EQUIPOS |  | 8d | 2024-05-01 | 2024-05-10 | 000262 FS-10d | 0.9d |  |  | QSC |  |  |  |  |  |  |  |  |  |  |  |
|  | 3 | **MEJORAMIENTO DE VÍAS EXISTENTES** |  |  | 2023-11-19 | 2023-12-03 |  |  |  |  |  |  |  |  |  |  |  |  |  |  |  |  |
|  | 1 | **MOVIMIENTO DE TIERRAS** |  |  | 2023-11-19 | 2023-12-03 |  |  |  |  |  |  |  |  |  |  |  |  |  |  |  |  |
| 000020 |  | ROCE Y LIMPIEZA DE MALEZA |  | 15d | 2023-11-19 | 2023-12-03 | 000016 FS-5d | 0d |  |  |  | 1.8.1.3.1.1 | 1913 | LACRAMARCA231001R8 | 2023-11-19 | 2023-11-19 | 2023-11-19 | 2023-12-04 | 2023-12-04 | 2023-12-04 | 20 | 20 |
| 000021 |  | MEJORAMIENTO DE VIAS EXISTENTES |  | 15d | 2023-11-19 | 2023-12-03 | 000020 SS | 0d |  |  |  | 1.8.1.3.1.2 | 1914 | LACRAMARCA231001R8 | 2023-11-19 | 2023-11-19 | 2023-11-19 | 2023-12-04 | 2023-12-04 | 2023-12-04 | 21 | 21 |
|  | 2 | **REPOSICIÓN DE ESTRUCTURAS** |  |  | 2023-11-19 | 2023-12-03 |  |  |  |  |  |  |  |  |  |  |  |  |  |  |  |  |
| 000023 |  | DEMOLICIÓN DE ESTRUCTURAS EXISTENTES |  | 15d | 2023-11-19 | 2023-12-03 | 000020 SS | 2d | 0d |  |  | 1.8.1.3.2.1 | 1916 | LACRAMARCA231001R8 | 2023-11-19 | 2023-11-19 | 2023-11-19 | 2023-12-04 | 2023-12-04 | 2023-12-04 | 23 | 23 |
| 000024 |  | REPOSICIÓN DE PASE DE AGUA TUBO HDPE Ø=18" |  | 15d | 2023-11-19 | 2023-12-03 | 000020 SS | 159d |  |  |  | 1.8.1.3.2.2 | 1917 | LACRAMARCA231001R8 | 2023-11-19 | 2024-04-26 | 2023-11-19 | 2023-12-04 | 2024-05-11 | 2023-12-04 | 24 | 24 |
| 000025 |  | REPOSICIÓN DE PASE DE AGUA TUBO HDPE Ø=36" |  | 15d | 2023-11-19 | 2023-12-03 | 000020 SS | 159d |  |  |  | 1.8.1.3.2.3 | 1918 | LACRAMARCA231001R8 | 2023-11-19 | 2024-04-26 | 2023-11-19 | 2023-12-04 | 2024-05-11 | 2023-12-04 | 25 | 25 |
| 000026 |  | SUMINISTRO Y MONTAJE DE PANELES DE C°A° 1.6mx1.0mx0.20m EN PASE DE AGUA |  | 15d | 2023-11-19 | 2023-12-03 | 000020 SS | 159d |  |  |  | 1.8.1.3.2.4 | 1919 | LACRAMARCA231001R8 | 2023-11-19 | 2024-04-26 | 2023-11-19 | 2023-12-04 | 2024-05-11 | 2023-12-04 | 26 | 26 |
| 000027 |  | SUMINISTRO Y MONTAJE DE PANELES DE C°A° 2.20mx1.0mx0.20m EN PASE DE AGUA |  | 15d | 2023-11-19 | 2023-12-03 | 000020 SS | 159d |  |  |  | 1.8.1.3.2.5 | 1920 | LACRAMARCA231001R8 | 2023-11-19 | 2024-04-26 | 2023-11-19 | 2023-12-04 | 2024-05-11 | 2023-12-04 | 27 | 27 |

| ID | WBS | Activity | Duration | Start | Finish | Predecessors | Total float | Free float | MSP Outline Number | MSP Unique ID | MSP Project Name | Imported Early Start | Imported Late Start | Imported Start | Imported Early Finish | Imported Late Finish | Imported Finish | MSP ID | MSP Task Order |
| --- | --- | --- | --- | --- | --- | --- | --- | --- | --- | --- | --- | --- | --- | --- | --- | --- | --- | --- | --- |
|  | 3 | **CABEZAL DE ENTRADA Y SALIDA** |  | 2023-11-19 | 2023-12-03 |  |  |  |  |  |  |  |  |  |  |  |  |  |  |
| 000029 |  | CONCRETOS | 15d | 2023-11-19 | 2023-12-03 | 000020 SS | 40d | 0d | 1.8.1.3.3.1 | 1922 | LACRAMARCA231001R8 | 2023-11-19 | 2023-12-29 | 2023-11-19 | 2023-12-04 | 2024-01-13 | 2023-12-04 | 29 | 29 |
| 000030 |  | ENCOFRADO Y DESENCOFRADO RECTO | 15d | 2023-11-19 | 2023-12-03 | 000020 SS | 159d |  | 1.8.1.3.3.2 | 1923 | LACRAMARCA231001R8 | 2023-11-19 | 2024-04-26 | 2023-11-19 | 2023-12-04 | 2024-05-11 | 2023-12-04 | 30 | 30 |
|  | 4 | **DESCOLMATACIÓN DE CAUCE y OBRAS AUXILIARES** |  | 2023-11-22 | 2024-03-13 |  |  |  |  |  |  |  |  |  |  |  |  |  |  |
| 000032 |  | DESBROCE Y LIMPIEZA EN ZONA NO BOSCOSA | 113d | 2023-11-22 | 2024-03-13 | 000021 FS-12d | 0d |  | 1.8.1.4.1 | 1925 | LACRAMARCA231001R8 | 2023-11-22 | 2023-11-22 | 2023-11-22 | 2024-03-14 | 2024-03-14 | 2024-03-14 | 32 | 32 |
| 000033 |  | DESCOLMATACIÓN DE CAUCE NATURAL DEL RÍO LACRAMARCA | 113d | 2023-11-22 | 2024-03-13 | 000032 SS | 58d |  | 1.8.1.4.2 | 1926 | LACRAMARCA231001R8 | 2023-11-22 | 2024-01-19 | 2023-11-22 | 2024-03-14 | 2024-05-11 | 2024-03-14 | 33 | 33 |
| 000034 |  | CONFORMACIÓN DE DESVIO EN CAUCE DE RÍO | 113d | 2023-11-22 | 2024-03-13 | 000032 SS | 58d |  | 1.8.1.4.3 | 1927 | LACRAMARCA231001R8 | 2023-11-22 | 2024-01-19 | 2023-11-22 | 2024-03-14 | 2024-05-11 | 2024-03-14 | 34 | 34 |
| 000035 |  | RELLENO NO ESTRUCTURAL CON MATERIAL PROPIO | 113d | 2023-11-22 | 2024-03-13 | 000032 SS | 58d |  | 1.8.1.4.4 | 1928 | LACRAMARCA231001R8 | 2023-11-22 | 2024-01-19 | 2023-11-22 | 2024-03-14 | 2024-05-11 | 2024-03-14 | 35 | 35 |
|  | 5 | **DIQUES DE TIERRA COMPACTADA CON ENROCADO** |  | 2023-11-27 | 2024-05-10 |  |  |  |  |  |  |  |  |  |  |  |  |  |  |
|  | 1 | **DIQUE DE TIERRA COMPACTADA A3-D-01** |  | 2024-02-17 | 2024-03-14 |  |  |  |  |  |  |  |  |  |  |  |  |  |  |
| 000038 |  | EXCAVACIÓN EN TERRENO NATURAL CON EQUIPO | 27d | 2024-02-17 | 2024-03-14 | 000048 | 57d | 0d | 1.8.1.5.1.1 | 1931 | LACRAMARCA231001R8 | 2024-02-17 | 2024-04-14 | 2024-02-17 | 2024-03-15 | 2024-05-11 | 2024-03-15 | 38 | 38 |
| 000039 |  | EXCAVACIÓN DE UÑA CON EQUIPO | 27d | 2024-02-17 | 2024-03-14 | 000038 SS | 57d |  | 1.8.1.5.1.2 | 1932 | LACRAMARCA231001R8 | 2024-02-17 | 2024-04-14 | 2024-02-17 | 2024-03-15 | 2024-05-11 | 2024-03-15 | 39 | 39 |
| 000040 |  | PERFILADO Y COMPACTACIÓN EN ZONA DE CORTE | 27d | 2024-02-17 | 2024-03-14 | 000038 SS | 57d |  | 1.8.1.5.1.3 | 1933 | LACRAMARCA231001R8 | 2024-02-17 | 2024-04-14 | 2024-02-17 | 2024-03-15 | 2024-05-11 | 2024-03-15 | 40 | 40 |
| 000041 |  | CONFORMACIÓN DE CUERPO DE DIQUE CON MATERIAL PROPIO | 27d | 2024-02-17 | 2024-03-14 | 000038 SS | 57d |  | 1.8.1.5.1.4 | 1934 | LACRAMARCA231001R8 | 2024-02-17 | 2024-04-14 | 2024-02-17 | 2024-03-15 | 2024-05-11 | 2024-03-15 | 41 | 41 |
| 000042 |  | CONFORMACIÓN DE CORONA DE DIQUE CON MATERIAL PROPIO | 27d | 2024-02-17 | 2024-03-14 | 000038 SS | 57d |  | 1.8.1.5.1.5 | 1935 | LACRAMARCA231001R8 | 2024-02-17 | 2024-04-14 | 2024-02-17 | 2024-03-15 | 2024-05-11 | 2024-03-15 | 42 | 42 |
| 000043 |  | GEOTEXTIL NO TEJIDO 400 G/M2, INC. COLOCACIÓN | 27d | 2024-02-17 | 2024-03-14 | 000038 SS | 57d |  | 1.8.1.5.1.6 | 1936 | LACRAMARCA231001R8 | 2024-02-17 | 2024-04-14 | 2024-02-17 | 2024-03-15 | 2024-05-11 | 2024-03-15 | 43 | 43 |
| 000044 |  | COLOCACION Y ACOMODO DE ROCA EN UÑA DE DIQUE | 27d | 2024-02-17 | 2024-03-14 | 000038 SS | 57d |  | 1.8.1.5.1.7 | 1937 | LACRAMARCA231001R8 | 2024-02-17 | 2024-04-14 | 2024-02-17 | 2024-03-15 | 2024-05-11 | 2024-03-15 | 44 | 44 |
| 000045 |  | COLOCACION Y ACOMODO DE ROCA EN TALUD DE DIQUE | 27d | 2024-02-17 | 2024-03-14 | 000038 SS | 57d |  | 1.8.1.5.1.8 | 1938 | LACRAMARCA231001R8 | 2024-02-17 | 2024-04-14 | 2024-02-17 | 2024-03-15 | 2024-05-11 | 2024-03-15 | 45 | 45 |
| 000046 |  | PREPARACIÓN DE FUNDACIÓN DE CUERPO DE DIQUE | 27d | 2024-02-17 | 2024-03-14 | 000038 SS | 57d |  | 1.8.1.5.1.9 | 1939 | LACRAMARCA231001R8 | 2024-02-17 | 2024-04-14 | 2024-02-17 | 2024-03-15 | 2024-05-11 | 2024-03-15 | 46 | 46 |
|  | 2 | **DIQUE DE TIERRA COMPACTADA A3-D-02** |  | 2023-11-27 | 2024-02-16 |  |  |  |  |  |  |  |  |  |  |  |  |  |  |
| 000048 |  | EXCAVACIÓN EN TERRENO NATURAL CON EQUIPO | 82d | 2023-11-27 | 2024-02-16 | 000032 SS+5d | 57d | 0d | 1.8.1.5.2.1 | 1941 | LACRAMARCA231001R8 | 2023-11-27 | 2024-01-23 | 2023-11-27 | 2024-02-17 | 2024-04-14 | 2024-02-17 | 48 | 48 |
| 000049 |  | EXCAVACIÓN DE UÑA CON EQUIPO | 82d | 2023-11-27 | 2024-02-16 | 000048 SS | 84d |  | 1.8.1.5.2.2 | 1942 | LACRAMARCA231001R8 | 2023-11-27 | 2024-02-19 | 2023-11-27 | 2024-02-17 | 2024-05-11 | 2024-02-17 | 49 | 49 |
| 000050 |  | PERFILADO Y COMPACTACIÓN EN ZONA DE CORTE | 82d | 2023-11-27 | 2024-02-16 | 000048 SS | 84d |  | 1.8.1.5.2.3 | 1943 | LACRAMARCA231001R8 | 2023-11-27 | 2024-02-19 | 2023-11-27 | 2024-02-17 | 2024-05-11 | 2024-02-17 | 50 | 50 |
| 000051 |  | CONFORMACIÓN DE CUERPO DE DIQUE CON MATERIAL PROPIO | 82d | 2023-11-27 | 2024-02-16 | 000048 SS | 84d | 0d | 1.8.1.5.2.4 | 1944 | LACRAMARCA231001R8 | 2023-11-27 | 2024-02-19 | 2023-11-27 | 2024-02-17 | 2024-05-11 | 2024-02-17 | 51 | 51 |
| 000052 |  | CONFORMACIÓN DE CORONA DE DIQUE CON MATERIAL PROPIO | 82d | 2023-11-27 | 2024-02-16 | 000048 SS | 84d |  | 1.8.1.5.2.5 | 1945 | LACRAMARCA231001R8 | 2023-11-27 | 2024-02-19 | 2023-11-27 | 2024-02-17 | 2024-05-11 | 2024-02-17 | 52 | 52 |
| 000053 |  | GEOTEXTIL NO TEJIDO 400 G/M2, INC. COLOCACIÓN | 82d | 2023-11-27 | 2024-02-16 | 000048 SS | 84d |  | 1.8.1.5.2.6 | 1946 | LACRAMARCA231001R8 | 2023-11-27 | 2024-02-19 | 2023-11-27 | 2024-02-17 | 2024-05-11 | 2024-02-17 | 53 | 53 |
| 000054 |  | COLOCACION Y ACOMODO DE ROCA EN UÑA DE DIQUE | 82d | 2023-11-27 | 2024-02-16 | 000048 SS | 84d |  | 1.8.1.5.2.7 | 1947 | LACRAMARCA231001R8 | 2023-11-27 | 2024-02-19 | 2023-11-27 | 2024-02-17 | 2024-05-11 | 2024-02-17 | 54 | 54 |
| 000055 |  | COLOCACION Y ACOMODO DE ROCA EN TALUD DE DIQUE | 82d | 2023-11-27 | 2024-02-16 | 000048 SS | 84d |  | 1.8.1.5.2.8 | 1948 | LACRAMARCA231001R8 | 2023-11-27 | 2024-02-19 | 2023-11-27 | 2024-02-17 | 2024-05-11 | 2024-02-17 | 55 | 55 |
| 000056 |  | PREPARACIÓN DE FUNDACIÓN DE CUERPO DE DIQUE | 82d | 2023-11-27 | 2024-02-16 | 000048 SS | 84d |  | 1.8.1.5.2.9 | 1949 | LACRAMARCA231001R8 | 2023-11-27 | 2024-02-19 | 2023-11-27 | 2024-02-17 | 2024-05-11 | 2024-02-17 | 56 | 56 |

| ID | WBS | Activity | Duration | Start | Finish | Predecessors | Total float | Free float | MSP Outline Number | MSP Unique ID | MSP Project Name | Imported Early Start | Imported Late Start | Imported Start | Imported Early Finish | Imported Late Finish | Imported Finish | MSP ID | MSP Task Order |
| --- | --- | --- | --- | --- | --- | --- | --- | --- | --- | --- | --- | --- | --- | --- | --- | --- | --- | --- | --- |
|  | 3 | **DIQUE DE TIERRA COMPACTADA A3-I-01** |  | 2024-02-17 | 2024-03-14 |  |  |  |  |  |  |  |  |  |  |  |  |  |  |
| 000058 |  | EXCAVACIÓN EN TERRENO NATURAL CON EQUIPO | 27d | 2024-02-17 | 2024-03-14 | 000048 | 57d | 0d | 1.8.1.5.3.1 | 1951 | LACRAMARCA231001R8 | 2024-02-17 | 2024-04-14 | 2024-02-17 | 2024-03-15 | 2024-05-11 | 2024-03-15 | 58 | 58 |
| 000059 |  | EXCAVACIÓN DE UÑA CON EQUIPO | 27d | 2024-02-17 | 2024-03-14 | 000058 SS | 57d |  | 1.8.1.5.3.2 | 1952 | LACRAMARCA231001R8 | 2024-02-17 | 2024-04-14 | 2024-02-17 | 2024-03-15 | 2024-05-11 | 2024-03-15 | 59 | 59 |
| 000060 |  | PERFILADO Y COMPACTACIÓN EN ZONA DE CORTE | 27d | 2024-02-17 | 2024-03-14 | 000058 SS | 57d |  | 1.8.1.5.3.3 | 1953 | LACRAMARCA231001R8 | 2024-02-17 | 2024-04-14 | 2024-02-17 | 2024-03-15 | 2024-05-11 | 2024-03-15 | 60 | 60 |
| 000061 |  | CONFORMACIÓN DE CUERPO DE DIQUE CON MATERIAL PROPIO | 27d | 2024-02-17 | 2024-03-14 | 000058 SS | 57d |  | 1.8.1.5.3.4 | 1954 | LACRAMARCA231001R8 | 2024-02-17 | 2024-04-14 | 2024-02-17 | 2024-03-15 | 2024-05-11 | 2024-03-15 | 61 | 61 |
| 000062 |  | CONFORMACIÓN DE CORONA DE DIQUE CON MATERIAL PROPIO | 27d | 2024-02-17 | 2024-03-14 | 000058 SS | 57d |  | 1.8.1.5.3.5 | 1955 | LACRAMARCA231001R8 | 2024-02-17 | 2024-04-14 | 2024-02-17 | 2024-03-15 | 2024-05-11 | 2024-03-15 | 62 | 62 |
| 000063 |  | GEOTEXTIL NO TEJIDO 400 G/M2, INC. COLOCACIÓN | 27d | 2024-02-17 | 2024-03-14 | 000058 SS | 57d |  | 1.8.1.5.3.6 | 1956 | LACRAMARCA231001R8 | 2024-02-17 | 2024-04-14 | 2024-02-17 | 2024-03-15 | 2024-05-11 | 2024-03-15 | 63 | 63 |
| 000064 |  | COLOCACION Y ACOMODO DE ROCA EN UÑA DE DIQUE | 27d | 2024-02-17 | 2024-03-14 | 000058 SS | 57d |  | 1.8.1.5.3.7 | 1957 | LACRAMARCA231001R8 | 2024-02-17 | 2024-04-14 | 2024-02-17 | 2024-03-15 | 2024-05-11 | 2024-03-15 | 64 | 64 |
| 000065 |  | COLOCACION Y ACOMODO DE ROCA EN TALUD DE DIQUE | 27d | 2024-02-17 | 2024-03-14 | 000058 SS | 57d |  | 1.8.1.5.3.8 | 1958 | LACRAMARCA231001R8 | 2024-02-17 | 2024-04-14 | 2024-02-17 | 2024-03-15 | 2024-05-11 | 2024-03-15 | 65 | 65 |
| 000066 |  | PREPARACIÓN DE FUNDACIÓN DE CUERPO DE DIQUE | 27d | 2024-02-17 | 2024-03-14 | 000058 SS | 57d |  | 1.8.1.5.3.9 | 1959 | LACRAMARCA231001R8 | 2024-02-17 | 2024-04-14 | 2024-02-17 | 2024-03-15 | 2024-05-11 | 2024-03-15 | 66 | 66 |
|  | 4 | **DIQUE DE TIERRA COMPACTADA A3-I-02** |  | 2024-04-09 | 2024-05-10 |  |  |  |  |  |  |  |  |  |  |  |  |  |  |
| 000068 |  | EXCAVACIÓN EN TERRENO NATURAL CON EQUIPO | 32d | 2024-04-09 | 2024-05-10 | 000084 | 0d |  | 1.8.1.5.4.1 | 1961 | LACRAMARCA231001R8 | 2024-04-09 | 2024-04-09 | 2024-04-09 | 2024-05-11 | 2024-05-11 | 2024-05-11 | 68 | 68 |
| 000069 |  | EXCAVACIÓN DE UÑA CON EQUIPO | 32d | 2024-04-09 | 2024-05-10 | 000068 SS | 0d |  | 1.8.1.5.4.2 | 1962 | LACRAMARCA231001R8 | 2024-04-09 | 2024-04-09 | 2024-04-09 | 2024-05-11 | 2024-05-11 | 2024-05-11 | 69 | 69 |
| 000070 |  | PERFILADO Y COMPACTACIÓN EN ZONA DE CORTE | 32d | 2024-04-09 | 2024-05-10 | 000068 SS | 0d |  | 1.8.1.5.4.3 | 1963 | LACRAMARCA231001R8 | 2024-04-09 | 2024-04-09 | 2024-04-09 | 2024-05-11 | 2024-05-11 | 2024-05-11 | 70 | 70 |
| 000071 |  | CONFORMACIÓN DE CUERPO DE DIQUE CON MATERIAL PROPIO | 32d | 2024-04-09 | 2024-05-10 | 000068 SS | 0d |  | 1.8.1.5.4.4 | 1964 | LACRAMARCA231001R8 | 2024-04-09 | 2024-04-09 | 2024-04-09 | 2024-05-11 | 2024-05-11 | 2024-05-11 | 71 | 71 |
| 000072 |  | CONFORMACIÓN DE CORONA DE DIQUE CON MATERIAL PROPIO | 32d | 2024-04-09 | 2024-05-10 | 000068 SS | 0d |  | 1.8.1.5.4.5 | 1965 | LACRAMARCA231001R8 | 2024-04-09 | 2024-04-09 | 2024-04-09 | 2024-05-11 | 2024-05-11 | 2024-05-11 | 72 | 72 |
| 000073 |  | GEOTEXTIL NO TEJIDO 400 G/M2, INC. COLOCACIÓN | 32d | 2024-04-09 | 2024-05-10 | 000068 SS | 0d |  | 1.8.1.5.4.6 | 1966 | LACRAMARCA231001R8 | 2024-04-09 | 2024-04-09 | 2024-04-09 | 2024-05-11 | 2024-05-11 | 2024-05-11 | 73 | 73 |
| 000074 |  | COLOCACION Y ACOMODO DE ROCA EN UÑA DE DIQUE | 32d | 2024-04-09 | 2024-05-10 | 000068 SS | 0d |  | 1.8.1.5.4.7 | 1967 | LACRAMARCA231001R8 | 2024-04-09 | 2024-04-09 | 2024-04-09 | 2024-05-11 | 2024-05-11 | 2024-05-11 | 74 | 74 |
| 000075 |  | COLOCACION Y ACOMODO DE ROCA EN TALUD DE DIQUE | 32d | 2024-04-09 | 2024-05-10 | 000068 SS | 0d |  | 1.8.1.5.4.8 | 1968 | LACRAMARCA231001R8 | 2024-04-09 | 2024-04-09 | 2024-04-09 | 2024-05-11 | 2024-05-11 | 2024-05-11 | 75 | 75 |
| 000076 |  | PREPARACIÓN DE FUNDACIÓN DE CUERPO DE DIQUE | 32d | 2024-04-09 | 2024-05-10 | 000068 SS | 0d |  | 1.8.1.5.4.9 | 1969 | LACRAMARCA231001R8 | 2024-04-09 | 2024-04-09 | 2024-04-09 | 2024-05-11 | 2024-05-11 | 2024-05-11 | 76 | 76 |
|  | 5 | **DIQUE DE TIERRA COMPACTADA A3-I-03** |  | 2023-11-27 | 2024-04-08 |  |  |  |  |  |  |  |  |  |  |  |  |  |  |
| 000078 |  | EXCAVACIÓN EN TERRENO NATURAL CON EQUIPO | 134d | 2023-11-27 | 2024-04-08 | 000032 SS+5d | 0d |  | 1.8.1.5.5.1 | 1971 | LACRAMARCA231001R8 | 2023-11-27 | 2023-11-27 | 2023-11-27 | 2024-04-09 | 2024-04-09 | 2024-04-09 | 78 | 78 |
| 000079 |  | EXCAVACIÓN DE UÑA CON EQUIPO | 134d | 2023-11-27 | 2024-04-08 | 000078 SS | 32d |  | 1.8.1.5.5.2 | 1972 | LACRAMARCA231001R8 | 2023-11-27 | 2023-12-29 | 2023-11-27 | 2024-04-09 | 2024-05-11 | 2024-04-09 | 79 | 79 |
| 000080 |  | PERFILADO Y COMPACTACIÓN EN ZONA DE CORTE | 134d | 2023-11-27 | 2024-04-08 | 000078 SS | 32d |  | 1.8.1.5.5.3 | 1973 | LACRAMARCA231001R8 | 2023-11-27 | 2023-12-29 | 2023-11-27 | 2024-04-09 | 2024-05-11 | 2024-04-09 | 80 | 80 |
| 000081 |  | CONFORMACIÓN DE CUERPO DE DIQUE CON MATERIAL PROPIO | 134d | 2023-11-27 | 2024-04-08 | 000078 SS | 32d |  | 1.8.1.5.5.4 | 1974 | LACRAMARCA231001R8 | 2023-11-27 | 2023-12-29 | 2023-11-27 | 2024-04-09 | 2024-05-11 | 2024-04-09 | 81 | 81 |
| 000082 |  | CONFORMACIÓN DE CORONA DE DIQUE CON MATERIAL PROPIO | 134d | 2023-11-27 | 2024-04-08 | 000078 SS | 32d |  | 1.8.1.5.5.5 | 1975 | LACRAMARCA231001R8 | 2023-11-27 | 2023-12-29 | 2023-11-27 | 2024-04-09 | 2024-05-11 | 2024-04-09 | 82 | 82 |
| 000083 |  | GEOTEXTIL NO TEJIDO 400 G/M2, INC. COLOCACIÓN | 134d | 2023-11-27 | 2024-04-08 | 000078 SS | 32d |  | 1.8.1.5.5.6 | 1976 | LACRAMARCA231001R8 | 2023-11-27 | 2023-12-29 | 2023-11-27 | 2024-04-09 | 2024-05-11 | 2024-04-09 | 83 | 83 |
| 000084 |  | COLOCACION Y ACOMODO DE ROCA EN UÑA DE DIQUE | 134d | 2023-11-27 | 2024-04-08 | 000078 SS | 0d |  | 1.8.1.5.5.7 | 1977 | LACRAMARCA231001R8 | 2023-11-27 | 2023-11-27 | 2023-11-27 | 2024-04-09 | 2024-04-09 | 2024-04-09 | 84 | 84 |
| 000085 |  | COLOCACION Y ACOMODO DE ROCA EN TALUD DE DIQUE | 134d | 2023-11-27 | 2024-04-08 | 000078 SS | 32d |  | 1.8.1.5.5.8 | 1978 | LACRAMARCA231001R8 | 2023-11-27 | 2023-12-29 | 2023-11-27 | 2024-04-09 | 2024-05-11 | 2024-04-09 | 85 | 85 |
| 000086 |  | PREPARACIÓN DE FUNDACIÓN DE CUERPO DE DIQUE | 134d | 2023-11-27 | 2024-04-08 | 000078 SS | 32d |  | 1.8.1.5.5.9 | 1979 | LACRAMARCA231001R8 | 2023-11-27 | 2023-12-29 | 2023-11-27 | 2024-04-09 | 2024-05-11 | 2024-04-09 | 86 | 86 |

| ID | WBS | Activity | Duration | Start | Finish | Predecessors | Total float | Free float | MSP Outline Number | MSP Unique ID | MSP Project Name | Imported Early Start | Imported Late Start | Imported Start | Imported Early Finish | Imported Late Finish | Imported Finish | MSP ID | MSP Task Order |
| --- | --- | --- | --- | --- | --- | --- | --- | --- | --- | --- | --- | --- | --- | --- | --- | --- | --- | --- | --- |
|  | 6 | **RAMPAS** |  | 2023-11-27 | 2023-11-29 |  |  |  |  |  |  |  |  |  |  |  |  |  |  |
| 000088 |  | EXCAVACIÓN EN TERRENO NATURAL CON EQUIPO | 3d | 2023-11-27 | 2023-11-29 | 000078 SS | 163d | 0d | 1.8.1.6.1 | 1981 | LACRAMARCA231001R8 | 2023-11-27 | 2024-05-08 | 2023-11-27 | 2023-11-30 | 2024-05-11 | 2023-11-30 | 88 | 88 |
| 000089 |  | CONFORMACIÓN DE CUERPO DE RAMPA CON MATERIAL PROPIO | 3d | 2023-11-27 | 2023-11-29 | 000088 SS | 163d |  | 1.8.1.6.2 | 1982 | LACRAMARCA231001R8 | 2023-11-27 | 2024-05-08 | 2023-11-27 | 2023-11-30 | 2024-05-11 | 2023-11-30 | 89 | 89 |
| 000090 |  | CONFORMACIÓN DE CORONACIÓN DE RAMPA | 3d | 2023-11-27 | 2023-11-29 | 000088 SS | 163d |  | 1.8.1.6.3 | 1983 | LACRAMARCA231001R8 | 2023-11-27 | 2024-05-08 | 2023-11-27 | 2023-11-30 | 2024-05-11 | 2023-11-30 | 90 | 90 |
|  | 2 | **OBRAS DE ARTE** |  | 2023-12-04 | 2024-03-31 |  |  |  |  |  |  |  |  |  |  |  |  |  |  |
|  | 1 | **CAPTACIÓN A3-CP-23-95** |  | 2023-12-04 | 2024-01-09 |  |  |  |  |  |  |  |  |  |  |  |  |  |  |
|  | 1 | **MOVIMIENTO DE TIERRAS** |  | 2023-12-04 | 2024-01-09 |  |  |  |  |  |  |  |  |  |  |  |  |  |  |
| 000094 |  | EXCAVACIÓN ESTRUCTURAL PARA OBRAS DE ARTE | 37d | 2023-12-04 | 2024-01-09 | 000029 | 122d | 0d | 1.8.2.1.1.1 | 1987 | LACRAMARCA231001R8 | 2023-12-04 | 2024-04-04 | 2023-12-04 | 2024-01-10 | 2024-05-11 | 2024-01-10 | 94 | 94 |
| 000095 |  | RELLENO ESTRUCTURAL PARA OBRAS DE ARTE, CON MATERIAL PROPIO | 37d | 2023-12-04 | 2024-01-09 | 000094 SS | 122d |  | 1.8.2.1.1.2 | 1988 | LACRAMARCA231001R8 | 2023-12-04 | 2024-04-04 | 2023-12-04 | 2024-01-10 | 2024-05-11 | 2024-01-10 | 95 | 95 |
|  | 2 | **OBRAS DE CONCRETO** |  | 2023-12-04 | 2024-01-09 |  |  |  |  |  |  |  |  |  |  |  |  |  |  |
| 000097 |  | CONCRETO f'c=100 kg/cm2 | 37d | 2023-12-04 | 2024-01-09 | 000029 | 122d |  | 1.8.2.1.2.1 | 1990 | LACRAMARCA231001R8 | 2023-12-04 | 2024-04-04 | 2023-12-04 | 2024-01-10 | 2024-05-11 | 2024-01-10 | 97 | 97 |
| 000098 |  | CONCRETO f'c=280 kg/cm2 | 37d | 2023-12-04 | 2024-01-09 | 000029 | 122d |  | 1.8.2.1.2.2 | 1991 | LACRAMARCA231001R8 | 2023-12-04 | 2024-04-04 | 2023-12-04 | 2024-01-10 | 2024-05-11 | 2024-01-10 | 98 | 98 |
| 000099 |  | CONCRETO CICLÓPEO f'c=280 kg/cm2 + 30% P.G. | 37d | 2023-12-04 | 2024-01-09 | 000029 | 122d |  | 1.8.2.1.2.3 | 1992 | LACRAMARCA231001R8 | 2023-12-04 | 2024-04-04 | 2023-12-04 | 2024-01-10 | 2024-05-11 | 2024-01-10 | 99 | 99 |
| 000100 |  | ENCOFRADO Y DESENCOFRADO RECTO | 37d | 2023-12-04 | 2024-01-09 | 000029 | 122d |  | 1.8.2.1.2.4 | 1993 | LACRAMARCA231001R8 | 2023-12-04 | 2024-04-04 | 2023-12-04 | 2024-01-10 | 2024-05-11 | 2024-01-10 | 100 | 100 |
| 000101 |  | ACERO DE REFUERZO fy=4200 kg/cm2 | 37d | 2023-12-04 | 2024-01-09 | 000029 | 122d |  | 1.8.2.1.2.5 | 1994 | LACRAMARCA231001R8 | 2023-12-04 | 2024-04-04 | 2023-12-04 | 2024-01-10 | 2024-05-11 | 2024-01-10 | 101 | 101 |
|  | 3 | **ESTRUCTURAS METALICAS** |  | 2023-12-04 | 2024-01-09 |  |  |  |  |  |  |  |  |  |  |  |  |  |  |
| 000103 |  | COMPUERTA METALICA PLANA DESLIZANTE DE 1.0x1.0m | 37d | 2023-12-04 | 2024-01-09 | 000029 | 122d |  | 1.8.2.1.3.1 | 1996 | LACRAMARCA231001R8 | 2023-12-04 | 2024-04-04 | 2023-12-04 | 2024-01-10 | 2024-05-11 | 2024-01-10 | 103 | 103 |
| 000104 |  | REJILLA DE 1.00x1.00m CON VARILLA DE 1/2" CADA 6,25cm | 37d | 2023-12-04 | 2024-01-09 | 000029 | 122d |  | 1.8.2.1.3.2 | 1997 | LACRAMARCA231001R8 | 2023-12-04 | 2024-04-04 | 2023-12-04 | 2024-01-10 | 2024-05-11 | 2024-01-10 | 104 | 104 |
| 000105 |  | BARANDA DE FIERRO GALVANIZADO 1 1/2" | 37d | 2023-12-04 | 2024-01-09 | 000029 | 122d |  | 1.8.2.1.3.3 | 1998 | LACRAMARCA231001R8 | 2023-12-04 | 2024-04-04 | 2023-12-04 | 2024-01-10 | 2024-05-11 | 2024-01-10 | 105 | 105 |
| 000106 |  | ESCALERA TIPO GATO | 37d | 2023-12-04 | 2024-01-09 | 000029 | 122d |  | 1.8.2.1.3.4 | 1999 | LACRAMARCA231001R8 | 2023-12-04 | 2024-04-04 | 2023-12-04 | 2024-01-10 | 2024-05-11 | 2024-01-10 | 106 | 106 |
| 000107 |  | TAPA METALICA CIRCULAR DN600 MM | 37d | 2023-12-04 | 2024-01-09 | 000029 | 122d |  | 1.8.2.1.3.5 | 2000 | LACRAMARCA231001R8 | 2023-12-04 | 2024-04-04 | 2023-12-04 | 2024-01-10 | 2024-05-11 | 2024-01-10 | 107 | 107 |
|  | 4 | **TUBERIAS** |  | 2023-12-04 | 2024-01-09 |  |  |  |  |  |  |  |  |  |  |  |  |  |  |
| 000109 |  | EXCAVACIÓN ESTRUCTURAL PARA OBRAS DE ARTE (Buzones) | 37d | 2023-12-04 | 2024-01-09 | 000029 | 122d |  | 1.8.2.1.4.1 | 2002 | LACRAMARCA231001R8 | 2023-12-04 | 2024-04-04 | 2023-12-04 | 2024-01-10 | 2024-05-11 | 2024-01-10 | 109 | 109 |
| 000110 |  | EXCAVACIÓN DE ZANJA | 37d | 2023-12-04 | 2024-01-09 | 000029 | 122d |  | 1.8.2.1.4.2 | 2003 | LACRAMARCA231001R8 | 2023-12-04 | 2024-04-04 | 2023-12-04 | 2024-01-10 | 2024-05-11 | 2024-01-10 | 110 | 110 |
| 000111 |  | RELLENO ESTRUCTURAL PARA OBRAS DE ARTE CON MATERIAL PROPIO (Buzones) | 37d | 2023-12-04 | 2024-01-09 | 000029 | 122d |  | 1.8.2.1.4.3 | 2004 | LACRAMARCA231001R8 | 2023-12-04 | 2024-04-04 | 2023-12-04 | 2024-01-10 | 2024-05-11 | 2024-01-10 | 111 | 111 |
| 000112 |  | CAMA DE ARENA | 37d | 2023-12-04 | 2024-01-09 | 000029 | 122d |  | 1.8.2.1.4.4 | 2005 | LACRAMARCA231001R8 | 2023-12-04 | 2024-04-04 | 2023-12-04 | 2024-01-10 | 2024-05-11 | 2024-01-10 | 112 | 112 |
| 000113 |  | RELLENO COMÚN PARA ZANJAS | 37d | 2023-12-04 | 2024-01-09 | 000029 | 122d |  | 1.8.2.1.4.5 | 2006 | LACRAMARCA231001R8 | 2023-12-04 | 2024-04-04 | 2023-12-04 | 2024-01-10 | 2024-05-11 | 2024-01-10 | 113 | 113 |
| 000114 |  | CONCRETO f'c=100 kg/cm2 (Buzones) | 37d | 2023-12-04 | 2024-01-09 | 000029 | 122d |  | 1.8.2.1.4.6 | 2007 | LACRAMARCA231001R8 | 2023-12-04 | 2024-04-04 | 2023-12-04 | 2024-01-10 | 2024-05-11 | 2024-01-10 | 114 | 114 |
| 000115 |  | CONCRETO f'c=280 kg/cm2 (Buzones) | 37d | 2023-12-04 | 2024-01-09 | 000029 | 122d |  | 1.8.2.1.4.7 | 2008 | LACRAMARCA231001R8 | 2023-12-04 | 2024-04-04 | 2023-12-04 | 2024-01-10 | 2024-05-11 | 2024-01-10 | 115 | 115 |
| 000116 |  | ENCOFRADO Y DESENCOFRADO RECTO | 37d | 2023-12-04 | 2024-01-09 | 000029 | 122d |  | 1.8.2.1.4.8 | 2009 | LACRAMARCA231001R8 | 2023-12-04 | 2024-04-04 | 2023-12-04 | 2024-01-10 | 2024-05-11 | 2024-01-10 | 116 | 116 |
| 000117 |  | ENCOFRADO Y DESENCOFRADO CURVO | 37d | 2023-12-04 | 2024-01-09 | 000029 | 122d |  | 1.8.2.1.4.9 | 2010 | LACRAMARCA231001R8 | 2023-12-04 | 2024-04-04 | 2023-12-04 | 2024-01-10 | 2024-05-11 | 2024-01-10 | 117 | 117 |
| 000118 |  | ACERO DE REFUERZO fy=4200 kg/cm2 (Buzones) | 37d | 2023-12-04 | 2024-01-09 | 000029 | 122d |  | 1.8.2.1.4.10 | 2011 | LACRAMARCA231001R8 | 2023-12-04 | 2024-04-04 | 2023-12-04 | 2024-01-10 | 2024-05-11 | 2024-01-10 | 118 | 118 |
| 000119 |  | SUMINISTRO E INSTALACIÓN DE TUBERÍA GRP DN600 mm SN2500 | 37d | 2023-12-04 | 2024-01-09 | 000029 | 122d |  | 1.8.2.1.4.11 | 2012 | LACRAMARCA231001R8 | 2023-12-04 | 2024-04-04 | 2023-12-04 | 2024-01-10 | 2024-05-11 | 2024-01-10 | 119 | 119 |

| ID | WBS | Activity | Duration | Start | Finish | Predecessors | Total float | Free float | MSP Outline Number | MSP Unique ID | MSP Project Name | Imported Early Start | Imported Late Start | Imported Start | Imported Early Finish | Imported Late Finish | Imported Finish | MSP ID | MSP Task Order |
| --- | --- | --- | --- | --- | --- | --- | --- | --- | --- | --- | --- | --- | --- | --- | --- | --- | --- | --- | --- |
|  | 5 | **CANAL** |  | 2023-12-04 | 2024-01-09 |  |  |  |  |  |  |  |  |  |  |  |  |  |  |
| 000121 |  | EXCAVACIÓN ESTRUCTURAL PARA OBRAS DE ARTE | 37d | 2023-12-04 | 2024-01-09 | 000029 | 122d |  | 1.8.2.1.5.1 | 2014 | LACRAMARCA231001R8 | 2023-12-04 | 2024-04-04 | 2023-12-04 | 2024-01-10 | 2024-05-11 | 2024-01-10 | 121 | 121 |
| 000122 |  | RELLENO ESTRUCTURAL PARA CANALES, CON MATERIAL PROPIO | 37d | 2023-12-04 | 2024-01-09 | 000029 | 122d |  | 1.8.2.1.5.2 | 2015 | LACRAMARCA231001R8 | 2023-12-04 | 2024-04-04 | 2023-12-04 | 2024-01-10 | 2024-05-11 | 2024-01-10 | 122 | 122 |
| 000123 |  | COLOCACIÓN DE CONCRETO f'c=100 kg/cm2 | 37d | 2023-12-04 | 2024-01-09 | 000029 | 122d |  | 1.8.2.1.5.3 | 2016 | LACRAMARCA231001R8 | 2023-12-04 | 2024-04-04 | 2023-12-04 | 2024-01-10 | 2024-05-11 | 2024-01-10 | 123 | 123 |
| 000124 |  | COLOCACIÓN DE CONCRETO f'c=280 kg/cm2 | 37d | 2023-12-04 | 2024-01-09 | 000029 | 122d |  | 1.8.2.1.5.4 | 2017 | LACRAMARCA231001R8 | 2023-12-04 | 2024-04-04 | 2023-12-04 | 2024-01-10 | 2024-05-11 | 2024-01-10 | 124 | 124 |
| 000125 |  | ENCOFRADO Y DESENCOFRADO RECTO | 37d | 2023-12-04 | 2024-01-09 | 000029 | 122d |  | 1.8.2.1.5.5 | 2018 | LACRAMARCA231001R8 | 2023-12-04 | 2024-04-04 | 2023-12-04 | 2024-01-10 | 2024-05-11 | 2024-01-10 | 125 | 125 |
| 000126 |  | ACERO DE REFUERZO fy=4200 kg/cm2 | 37d | 2023-12-04 | 2024-01-09 | 000029 | 122d |  | 1.8.2.1.5.6 | 2019 | LACRAMARCA231001R8 | 2023-12-04 | 2024-04-04 | 2023-12-04 | 2024-01-10 | 2024-05-11 | 2024-01-10 | 126 | 126 |
| 000127 |  | JUNTA WATER STOP SIN BULBO 150 mm | 37d | 2023-12-04 | 2024-01-09 | 000029 | 122d |  | 1.8.2.1.5.7 | 2020 | LACRAMARCA231001R8 | 2023-12-04 | 2024-04-04 | 2023-12-04 | 2024-01-10 | 2024-05-11 | 2024-01-10 | 127 | 127 |
|  | 6 | **OBRAS DE DESCARGA** |  | 2023-12-04 | 2024-01-09 |  |  |  |  |  |  |  |  |  |  |  |  |  |  |
| 000129 |  | EXCAVACIÓN ESTRUCTURAL PARA OBRAS DE ARTE | 37d | 2023-12-04 | 2024-01-09 | 000029 | 122d |  | 1.8.2.1.6.1 | 2022 | LACRAMARCA231001R8 | 2023-12-04 | 2024-04-04 | 2023-12-04 | 2024-01-10 | 2024-05-11 | 2024-01-10 | 129 | 129 |
| 000130 |  | RELLENO ESTRUCTURAL PARA OBRAS DE ARTE CON MATERIAL PROPIO | 37d | 2023-12-04 | 2024-01-09 | 000029 | 40d | 0d | 1.8.2.1.6.2 | 2023 | LACRAMARCA231001R8 | 2023-12-04 | 2024-01-13 | 2023-12-04 | 2024-01-10 | 2024-02-19 | 2024-01-10 | 130 | 130 |
| 000131 |  | CONCRETO f'c=100 kg/cm2 | 37d | 2023-12-04 | 2024-01-09 | 000029 | 122d |  | 1.8.2.1.6.3 | 2024 | LACRAMARCA231001R8 | 2023-12-04 | 2024-04-04 | 2023-12-04 | 2024-01-10 | 2024-05-11 | 2024-01-10 | 131 | 131 |
| 000132 |  | CONCRETO f'c=280 kg/cm2 | 37d | 2023-12-04 | 2024-01-09 | 000029 | 122d |  | 1.8.2.1.6.4 | 2025 | LACRAMARCA231001R8 | 2023-12-04 | 2024-04-04 | 2023-12-04 | 2024-01-10 | 2024-05-11 | 2024-01-10 | 132 | 132 |
| 000133 |  | ENCOFRADO Y DESENCOFRADO RECTO | 37d | 2023-12-04 | 2024-01-09 | 000029 | 122d |  | 1.8.2.1.6.5 | 2026 | LACRAMARCA231001R8 | 2023-12-04 | 2024-04-04 | 2023-12-04 | 2024-01-10 | 2024-05-11 | 2024-01-10 | 133 | 133 |
| 000134 |  | ACERO DE REFUERZO fy=4200 kg/cm2 | 37d | 2023-12-04 | 2024-01-09 | 000029 | 122d |  | 1.8.2.1.6.6 | 2027 | LACRAMARCA231001R8 | 2023-12-04 | 2024-04-04 | 2023-12-04 | 2024-01-10 | 2024-05-11 | 2024-01-10 | 134 | 134 |
| 000135 |  | JUNTA WATER STOP SIN BULBO 150 mm | 37d | 2023-12-04 | 2024-01-09 | 000029 | 122d |  | 1.8.2.1.6.7 | 2028 | LACRAMARCA231001R8 | 2023-12-04 | 2024-04-04 | 2023-12-04 | 2024-01-10 | 2024-05-11 | 2024-01-10 | 135 | 135 |
| 000136 |  | COMPUERTA METALICA PLANA DESLIZANTE | 37d | 2023-12-04 | 2024-01-09 | 000029 | 122d |  | 1.8.2.1.6.8 | 2029 | LACRAMARCA231001R8 | 2023-12-04 | 2024-04-04 | 2023-12-04 | 2024-01-10 | 2024-05-11 | 2024-01-10 | 136 | 136 |
|  | 2 | **CAPTACIÓN A3-CP-21-05** |  | 2024-01-10 | 2024-02-01 |  |  |  |  |  |  |  |  |  |  |  |  |  |  |
|  | 1 | **MOVIMIENTO DE TIERRAS** |  | 2024-01-10 | 2024-02-01 |  |  |  |  |  |  |  |  |  |  |  |  |  |  |
| 000139 |  | EXCAVACIÓN ESTRUCTURAL PARA OBRAS DE ARTE | 23d | 2024-01-10 | 2024-02-01 | 000130 | 40d | 0d | 1.8.2.2.1.1 | 2032 | LACRAMARCA231001R8 | 2024-01-10 | 2024-02-19 | 2024-01-10 | 2024-02-02 | 2024-03-13 | 2024-02-02 | 139 | 139 |
| 000140 |  | RELLENO ESTRUCTURAL PARA OBRAS DE ARTE, CON MATERIAL PROPIO | 23d | 2024-01-10 | 2024-02-01 | 000139 SS | 99d |  | 1.8.2.2.1.2 | 2033 | LACRAMARCA231001R8 | 2024-01-10 | 2024-04-18 | 2024-01-10 | 2024-02-02 | 2024-05-11 | 2024-02-02 | 140 | 140 |
|  | 2 | **OBRAS DE CONCRETO** |  | 2024-01-10 | 2024-02-01 |  |  |  |  |  |  |  |  |  |  |  |  |  |  |
| 000142 |  | CONCRETO f'c=100 kg/cm2 | 23d | 2024-01-10 | 2024-02-01 | 000139 SS | 99d |  | 1.8.2.2.2.1 | 2035 | LACRAMARCA231001R8 | 2024-01-10 | 2024-04-18 | 2024-01-10 | 2024-02-02 | 2024-05-11 | 2024-02-02 | 142 | 142 |
| 000143 |  | CONCRETO f'c=280 kg/cm2 | 23d | 2024-01-10 | 2024-02-01 | 000139 SS | 99d |  | 1.8.2.2.2.2 | 2036 | LACRAMARCA231001R8 | 2024-01-10 | 2024-04-18 | 2024-01-10 | 2024-02-02 | 2024-05-11 | 2024-02-02 | 143 | 143 |
| 000144 |  | CONCRETO CICLÓPEO f'c=280 kg/cm2 + 30% P.G. | 23d | 2024-01-10 | 2024-02-01 | 000139 SS | 99d |  | 1.8.2.2.2.3 | 2037 | LACRAMARCA231001R8 | 2024-01-10 | 2024-04-18 | 2024-01-10 | 2024-02-02 | 2024-05-11 | 2024-02-02 | 144 | 144 |
| 000145 |  | ENCOFRADO Y DESENCOFRADO RECTO | 23d | 2024-01-10 | 2024-02-01 | 000139 SS | 99d |  | 1.8.2.2.2.4 | 2038 | LACRAMARCA231001R8 | 2024-01-10 | 2024-04-18 | 2024-01-10 | 2024-02-02 | 2024-05-11 | 2024-02-02 | 145 | 145 |
| 000146 |  | ACERO DE REFUERZO fy=4200 kg/cm2 | 23d | 2024-01-10 | 2024-02-01 | 000139 SS | 99d |  | 1.8.2.2.2.5 | 2039 | LACRAMARCA231001R8 | 2024-01-10 | 2024-04-18 | 2024-01-10 | 2024-02-02 | 2024-05-11 | 2024-02-02 | 146 | 146 |

| ID | WBS | Activity | Duration | Start | Finish | Predecessors | Total float | Free float | MSP Outline Number | MSP Unique ID | MSP Project Name | Imported Early Start | Imported Late Start | Imported Start | Imported Early Finish | Imported Late Finish | Imported Finish | MSP ID | MSP Task Order |
| --- | --- | --- | --- | --- | --- | --- | --- | --- | --- | --- | --- | --- | --- | --- | --- | --- | --- | --- | --- |
|  | 3 | **ESTRUCTURAS METALICAS** |  | 2024-01-10 | 2024-02-01 |  |  |  |  |  |  |  |  |  |  |  |  |  |  |
| 000148 |  | COMPUERTA METALICA PLANA DESLIZANTE DE 1.0x1.0m | 23d | 2024-01-10 | 2024-02-01 | 000139 SS | 99d |  | 1.8.2.2.3.1 | 2041 | LACRAMARCA231001R8 | 2024-01-10 | 2024-04-18 | 2024-01-10 | 2024-02-02 | 2024-05-11 | 2024-02-02 | 148 | 148 |
| 000149 |  | REJILLA DE 1.00x1.00m CON VARILLA DE 1/2 CADA 6,25cm | 23d | 2024-01-10 | 2024-02-01 | 000139 SS | 99d |  | 1.8.2.2.3.2 | 2042 | LACRAMARCA231001R8 | 2024-01-10 | 2024-04-18 | 2024-01-10 | 2024-02-02 | 2024-05-11 | 2024-02-02 | 149 | 149 |
| 000150 |  | BARANDA DE FIERRO GALVANIZADO 1 1/2" | 23d | 2024-01-10 | 2024-02-01 | 000139 SS | 99d |  | 1.8.2.2.3.3 | 2043 | LACRAMARCA231001R8 | 2024-01-10 | 2024-04-18 | 2024-01-10 | 2024-02-02 | 2024-05-11 | 2024-02-02 | 150 | 150 |
| 000151 |  | ESCALERA TIPO GATO | 23d | 2024-01-10 | 2024-02-01 | 000139 SS | 99d |  | 1.8.2.2.3.4 | 2044 | LACRAMARCA231001R8 | 2024-01-10 | 2024-04-18 | 2024-01-10 | 2024-02-02 | 2024-05-11 | 2024-02-02 | 151 | 151 |
| 000152 |  | TAPA METALICA CIRCULAR DN600 MM | 23d | 2024-01-10 | 2024-02-01 | 000139 SS | 99d |  | 1.8.2.2.3.5 | 2045 | LACRAMARCA231001R8 | 2024-01-10 | 2024-04-18 | 2024-01-10 | 2024-02-02 | 2024-05-11 | 2024-02-02 | 152 | 152 |
|  | 4 | **TUBERIA** |  | 2024-01-10 | 2024-02-01 |  |  |  |  |  |  |  |  |  |  |  |  |  |  |
| 000154 |  | EXCAVACIÓN ESTRUCTURAL PARA OBRAS DE ARTE (Buzones) | 23d | 2024-01-10 | 2024-02-01 | 000139 SS | 99d |  | 1.8.2.2.4.1 | 2047 | LACRAMARCA231001R8 | 2024-01-10 | 2024-04-18 | 2024-01-10 | 2024-02-02 | 2024-05-11 | 2024-02-02 | 154 | 154 |
| 000155 |  | EXCAVACIÓN DE ZANJA | 23d | 2024-01-10 | 2024-02-01 | 000139 SS | 99d |  | 1.8.2.2.4.2 | 2048 | LACRAMARCA231001R8 | 2024-01-10 | 2024-04-18 | 2024-01-10 | 2024-02-02 | 2024-05-11 | 2024-02-02 | 155 | 155 |
| 000156 |  | RELLENO ESTRUCTURAL PARA OBRAS DE ARTE CON MATERIAL PROPIO | 23d | 2024-01-10 | 2024-02-01 | 000139 SS | 99d |  | 1.8.2.2.4.3 | 2049 | LACRAMARCA231001R8 | 2024-01-10 | 2024-04-18 | 2024-01-10 | 2024-02-02 | 2024-05-11 | 2024-02-02 | 156 | 156 |
| 000157 |  | CAMA DE ARENA | 23d | 2024-01-10 | 2024-02-01 | 000139 SS | 99d |  | 1.8.2.2.4.4 | 2050 | LACRAMARCA231001R8 | 2024-01-10 | 2024-04-18 | 2024-01-10 | 2024-02-02 | 2024-05-11 | 2024-02-02 | 157 | 157 |
| 000158 |  | RELLENO SELECCIONADO PARA ZANJAS CON MATERIAL PROPIO | 23d | 2024-01-10 | 2024-02-01 | 000139 SS | 99d |  | 1.8.2.2.4.5 | 2051 | LACRAMARCA231001R8 | 2024-01-10 | 2024-04-18 | 2024-01-10 | 2024-02-02 | 2024-05-11 | 2024-02-02 | 158 | 158 |
| 000159 |  | RELLENO COMÚN PARA ZANJAS | 23d | 2024-01-10 | 2024-02-01 | 000139 SS | 99d |  | 1.8.2.2.4.6 | 2052 | LACRAMARCA231001R8 | 2024-01-10 | 2024-04-18 | 2024-01-10 | 2024-02-02 | 2024-05-11 | 2024-02-02 | 159 | 159 |
| 000160 |  | CONCRETO f'c=100 kg/cm2 (Buzones) | 23d | 2024-01-10 | 2024-02-01 | 000139 SS | 99d |  | 1.8.2.2.4.7 | 2053 | LACRAMARCA231001R8 | 2024-01-10 | 2024-04-18 | 2024-01-10 | 2024-02-02 | 2024-05-11 | 2024-02-02 | 160 | 160 |
| 000161 |  | CONCRETO f'c=280 kg/cm2 (Buzones) | 23d | 2024-01-10 | 2024-02-01 | 000139 SS | 99d |  | 1.8.2.2.4.8 | 2054 | LACRAMARCA231001R8 | 2024-01-10 | 2024-04-18 | 2024-01-10 | 2024-02-02 | 2024-05-11 | 2024-02-02 | 161 | 161 |
| 000162 |  | ENCOFRADO Y DESENCOFRADO RECTO | 23d | 2024-01-10 | 2024-02-01 | 000139 SS | 99d |  | 1.8.2.2.4.9 | 2055 | LACRAMARCA231001R8 | 2024-01-10 | 2024-04-18 | 2024-01-10 | 2024-02-02 | 2024-05-11 | 2024-02-02 | 162 | 162 |
| 000163 |  | ENCOFRADO Y DESENCOFRADO CURVO | 23d | 2024-01-10 | 2024-02-01 | 000139 SS | 99d |  | 1.8.2.2.4.10 | 2056 | LACRAMARCA231001R8 | 2024-01-10 | 2024-04-18 | 2024-01-10 | 2024-02-02 | 2024-05-11 | 2024-02-02 | 163 | 163 |
| 000164 |  | ACERO DE REFUERZO fy=4200 kg/cm2 | 23d | 2024-01-10 | 2024-02-01 | 000139 SS | 99d |  | 1.8.2.2.4.11 | 2057 | LACRAMARCA231001R8 | 2024-01-10 | 2024-04-18 | 2024-01-10 | 2024-02-02 | 2024-05-11 | 2024-02-02 | 164 | 164 |
| 000165 |  | SUMINISTRO E INSTALACIÓN DE TUBERÍA GRP DN600 mm SN2500 | 23d | 2024-01-10 | 2024-02-01 | 000139 SS | 99d |  | 1.8.2.2.4.12 | 2058 | LACRAMARCA231001R8 | 2024-01-10 | 2024-04-18 | 2024-01-10 | 2024-02-02 | 2024-05-11 | 2024-02-02 | 165 | 165 |
|  | 5 | **CANALES** |  | 2024-01-10 | 2024-02-01 |  |  |  |  |  |  |  |  |  |  |  |  |  |  |
| 000167 |  | EXCAVACIÓN ESTRUCTURAL PARA OBRAS DE ARTE | 23d | 2024-01-10 | 2024-02-01 | 000139 SS | 99d |  | 1.8.2.2.5.1 | 2060 | LACRAMARCA231001R8 | 2024-01-10 | 2024-04-18 | 2024-01-10 | 2024-02-02 | 2024-05-11 | 2024-02-02 | 167 | 167 |
| 000168 |  | RELLENO ESTRUCTURAL PARA CANALES, CON MATERIAL PROPIO | 23d | 2024-01-10 | 2024-02-01 | 000139 SS | 99d |  | 1.8.2.2.5.2 | 2061 | LACRAMARCA231001R8 | 2024-01-10 | 2024-04-18 | 2024-01-10 | 2024-02-02 | 2024-05-11 | 2024-02-02 | 168 | 168 |
| 000169 |  | COLOCACIÓN DE CONCRETO f'c=100 kg/cm2 | 23d | 2024-01-10 | 2024-02-01 | 000139 SS | 99d |  | 1.8.2.2.5.3 | 2062 | LACRAMARCA231001R8 | 2024-01-10 | 2024-04-18 | 2024-01-10 | 2024-02-02 | 2024-05-11 | 2024-02-02 | 169 | 169 |
| 000170 |  | COLOCACIÓN DE CONCRETO f'c=280 kg/cm2 | 23d | 2024-01-10 | 2024-02-01 | 000139 SS | 40d | 0d | 1.8.2.2.5.4 | 2063 | LACRAMARCA231001R8 | 2024-01-10 | 2024-02-19 | 2024-01-10 | 2024-02-02 | 2024-03-13 | 2024-02-02 | 170 | 170 |
| 000171 |  | ENCOFRADO Y DESENCOFRADO | 23d | 2024-01-10 | 2024-02-01 | 000139 SS | 99d |  | 1.8.2.2.5.5 | 2064 | LACRAMARCA231001R8 | 2024-01-10 | 2024-04-18 | 2024-01-10 | 2024-02-02 | 2024-05-11 | 2024-02-02 | 171 | 171 |
| 000172 |  | ACERO DE REFUERZO fy=4200 kg/cm2 | 23d | 2024-01-10 | 2024-02-01 | 000139 SS | 99d |  | 1.8.2.2.5.6 | 2065 | LACRAMARCA231001R8 | 2024-01-10 | 2024-04-18 | 2024-01-10 | 2024-02-02 | 2024-05-11 | 2024-02-02 | 172 | 172 |
| 000173 |  | JUNTA WATER STOP SIN BULBO 150 mm | 23d | 2024-01-10 | 2024-02-01 | 000139 SS | 99d |  | 1.8.2.2.5.7 | 2066 | LACRAMARCA231001R8 | 2024-01-10 | 2024-04-18 | 2024-01-10 | 2024-02-02 | 2024-05-11 | 2024-02-02 | 173 | 173 |

| ID | WBS | Activity | Duration | Start | Finish | Predecessors | Total float | Free float | MSP Outline Number | MSP Unique ID | MSP Project Name | Imported Early Start | Imported Late Start | Imported Start | Imported Early Finish | Imported Late Finish | Imported Finish | MSP ID | MSP Task Order |
| --- | --- | --- | --- | --- | --- | --- | --- | --- | --- | --- | --- | --- | --- | --- | --- | --- | --- | --- | --- |
|  | 3 | **RETORNO A3-OA-RE-D-21-55** |  | 2024-02-02 | 2024-02-20 |  |  |  |  |  |  |  |  |  |  |  |  |  |  |
|  | 1 | **MOVIMIENTO DE TIERRAS** |  | 2024-02-02 | 2024-02-20 |  |  |  |  |  |  |  |  |  |  |  |  |  |  |
| 000176 |  | EXCAVACIÓN ESTRUCTURAL PARA OBRAS DE ARTE | 19d | 2024-02-02 | 2024-02-20 | 000170 | 40d | 0d | 1.8.2.3.1.1 | 2069 | LACRAMARCA231001R8 | 2024-02-02 | 2024-03-13 | 2024-02-02 | 2024-02-21 | 2024-04-01 | 2024-02-21 | 176 | 176 |
| 000177 |  | RELLENO ESTRUCTURAL PARA OBRAS DE ARTE, CON MATERIAL PROPIO | 19d | 2024-02-02 | 2024-02-20 | 000176 SS | 80d |  | 1.8.2.3.1.2 | 2070 | LACRAMARCA231001R8 | 2024-02-02 | 2024-04-22 | 2024-02-02 | 2024-02-21 | 2024-05-11 | 2024-02-21 | 177 | 177 |
|  | 2 | **OBRAS DE CONCRETO** |  | 2024-02-02 | 2024-02-20 |  |  |  |  |  |  |  |  |  |  |  |  |  |  |
| 000179 |  | CONCRETO f'c=100 kg/cm2 | 19d | 2024-02-02 | 2024-02-20 | 000176 SS | 80d |  | 1.8.2.3.2.1 | 2072 | LACRAMARCA231001R8 | 2024-02-02 | 2024-04-22 | 2024-02-02 | 2024-02-21 | 2024-05-11 | 2024-02-21 | 179 | 179 |
| 000180 |  | CONCRETO f'c=280 kg/cm2 | 19d | 2024-02-02 | 2024-02-20 | 000176 SS | 40d | 0d | 1.8.2.3.2.2 | 2073 | LACRAMARCA231001R8 | 2024-02-02 | 2024-03-13 | 2024-02-02 | 2024-02-21 | 2024-04-01 | 2024-02-21 | 180 | 180 |
| 000181 |  | CONCRETO CICLÓPEO f'c=280 kg/cm2 + 30% P.G. | 19d | 2024-02-02 | 2024-02-20 | 000176 SS | 80d |  | 1.8.2.3.2.3 | 2074 | LACRAMARCA231001R8 | 2024-02-02 | 2024-04-22 | 2024-02-02 | 2024-02-21 | 2024-05-11 | 2024-02-21 | 181 | 181 |
| 000182 |  | ENCOFRADO Y DESENCOFRADO | 19d | 2024-02-02 | 2024-02-20 | 000176 SS | 80d |  | 1.8.2.3.2.4 | 2075 | LACRAMARCA231001R8 | 2024-02-02 | 2024-04-22 | 2024-02-02 | 2024-02-21 | 2024-05-11 | 2024-02-21 | 182 | 182 |
| 000183 |  | ACERO DE REFUERZO fy=4200 kg/cm2 | 19d | 2024-02-02 | 2024-02-20 | 000176 SS | 80d |  | 1.8.2.3.2.5 | 2076 | LACRAMARCA231001R8 | 2024-02-02 | 2024-04-22 | 2024-02-02 | 2024-02-21 | 2024-05-11 | 2024-02-21 | 183 | 183 |
| 000184 |  | JUNTA WATER STOP SIN BULBO 150 mm | 19d | 2024-02-02 | 2024-02-20 | 000176 SS | 80d |  | 1.8.2.3.2.6 | 2077 | LACRAMARCA231001R8 | 2024-02-02 | 2024-04-22 | 2024-02-02 | 2024-02-21 | 2024-05-11 | 2024-02-21 | 184 | 184 |
|  | 3 | **ESTRUCTURAS METALICAS** |  | 2024-02-02 | 2024-02-20 |  |  |  |  |  |  |  |  |  |  |  |  |  |  |
| 000186 |  | COMPUERTA METALICA PLANA DESLIZANTE DE 1.0x1.6 m | 19d | 2024-02-02 | 2024-02-20 | 000176 SS | 80d |  | 1.8.2.3.3.1 | 2079 | LACRAMARCA231001R8 | 2024-02-02 | 2024-04-22 | 2024-02-02 | 2024-02-21 | 2024-05-11 | 2024-02-21 | 186 | 186 |
| 000187 |  | BARANDA DE FIERRO GALVANIZADO 1 1/2" | 19d | 2024-02-02 | 2024-02-20 | 000176 SS | 80d |  | 1.8.2.3.3.2 | 2080 | LACRAMARCA231001R8 | 2024-02-02 | 2024-04-22 | 2024-02-02 | 2024-02-21 | 2024-05-11 | 2024-02-21 | 187 | 187 |
|  | 4 | **REPOSICIÓN DE CANALES** |  | 2024-02-21 | 2024-03-31 |  |  |  |  |  |  |  |  |  |  |  |  |  |  |
|  | 1 | **REPOSICIÓN DE CANAL 1** |  | 2024-02-21 | 2024-03-12 |  |  |  |  |  |  |  |  |  |  |  |  |  |  |
|  | 1 | **MOVIMIENTO DE TIERRAS** |  | 2024-02-21 | 2024-03-12 |  |  |  |  |  |  |  |  |  |  |  |  |  |  |
| 000191 |  | DEMOLICIÓN DE ESTRUCTURAS EXISTENTES | 21d | 2024-02-21 | 2024-03-12 | 000180 | 40d | 0d | 1.8.2.4.1.1.1 | 2084 | LACRAMARCA231001R8 | 2024-02-21 | 2024-04-01 | 2024-02-21 | 2024-03-13 | 2024-04-22 | 2024-03-13 | 191 | 191 |
| 000192 |  | EXCAVACIÓN EN TERRENO NATURAL CON EQUIPO | 21d | 2024-02-21 | 2024-03-12 | 000191 SS | 59d |  | 1.8.2.4.1.1.2 | 2085 | LACRAMARCA231001R8 | 2024-02-21 | 2024-04-20 | 2024-02-21 | 2024-03-13 | 2024-05-11 | 2024-03-13 | 192 | 192 |
| 000193 |  | RELLENO ESTRUCTURAL PARA OBRAS DE ARTE CON MATERIAL PROPIO | 21d | 2024-02-21 | 2024-03-12 | 000191 SS | 59d |  | 1.8.2.4.1.1.3 | 2086 | LACRAMARCA231001R8 | 2024-02-21 | 2024-04-20 | 2024-02-21 | 2024-03-13 | 2024-05-11 | 2024-03-13 | 193 | 193 |
|  | 2 | **OBRAS DE CONCRETO** |  | 2024-02-21 | 2024-03-12 |  |  |  |  |  |  |  |  |  |  |  |  |  |  |
| 000195 |  | ENCOFRADO Y DESENCOFRADO RECTO | 21d | 2024-02-21 | 2024-03-12 | 000191 SS | 59d |  | 1.8.2.4.1.2.1 | 2088 | LACRAMARCA231001R8 | 2024-02-21 | 2024-04-20 | 2024-02-21 | 2024-03-13 | 2024-05-11 | 2024-03-13 | 195 | 195 |
| 000196 |  | ACERO DE REFUERZO fy=4200 kg/cm2 | 21d | 2024-02-21 | 2024-03-12 | 000191 SS | 59d |  | 1.8.2.4.1.2.2 | 2089 | LACRAMARCA231001R8 | 2024-02-21 | 2024-04-20 | 2024-02-21 | 2024-03-13 | 2024-05-11 | 2024-03-13 | 196 | 196 |
| 000197 |  | CONCRETO f'c=100 kg/cm2 | 21d | 2024-02-21 | 2024-03-12 | 000191 SS | 40d | 0d | 1.8.2.4.1.2.3 | 2090 | LACRAMARCA231001R8 | 2024-02-21 | 2024-04-01 | 2024-02-21 | 2024-03-13 | 2024-04-22 | 2024-03-13 | 197 | 197 |
| 000198 |  | CONCRETO f'c=280 kg/cm2 | 21d | 2024-02-21 | 2024-03-12 | 000191 SS | 59d |  | 1.8.2.4.1.2.4 | 2091 | LACRAMARCA231001R8 | 2024-02-21 | 2024-04-20 | 2024-02-21 | 2024-03-13 | 2024-05-11 | 2024-03-13 | 198 | 198 |
| 000199 |  | JUNTA WATER STOP 6" | 21d | 2024-02-21 | 2024-03-12 | 000191 SS | 59d |  | 1.8.2.4.1.2.5 | 2092 | LACRAMARCA231001R8 | 2024-02-21 | 2024-04-20 | 2024-02-21 | 2024-03-13 | 2024-05-11 | 2024-03-13 | 199 | 199 |
| 000200 |  | MAMPOSTERIA DE PIEDRA, e=20cm, ACABADO CARA VISTA | 21d | 2024-02-21 | 2024-03-12 | 000191 SS | 59d |  | 1.8.2.4.1.2.6 | 2093 | LACRAMARCA231001R8 | 2024-02-21 | 2024-04-20 | 2024-02-21 | 2024-03-13 | 2024-05-11 | 2024-03-13 | 200 | 200 |

| ID | WBS | Activity | Duration | Start | Finish | Predecessors | Total float | Free float | MSP Outline Number | MSP Unique ID | MSP Project Name | Imported Early Start | Imported Late Start | Imported Start | Imported Early Finish | Imported Late Finish | Imported Finish | MSP ID | MSP Task Order |
| --- | --- | --- | --- | --- | --- | --- | --- | --- | --- | --- | --- | --- | --- | --- | --- | --- | --- | --- | --- |
|  | 2 | **REPOSICIÓN DE CANAL 3** |  | 2024-03-13 | 2024-03-31 |  |  |  |  |  |  |  |  |  |  |  |  |  |  |
|  | 1 | **MOVIMIENTO DE TIERRAS** |  | 2024-03-13 | 2024-03-31 |  |  |  |  |  |  |  |  |  |  |  |  |  |  |
| 000203 |  | DEMOLICIÓN DE ESTRUCTURAS EXISTENTES | 19d | 2024-03-13 | 2024-03-31 | 000197 | 40d | 0d | 1.8.2.4.2.1.1 | 2096 | LACRAMARCA231001R8 | 2024-03-13 | 2024-04-22 | 2024-03-13 | 2024-04-01 | 2024-05-11 | 2024-04-01 | 203 | 203 |
| 000204 |  | EXCAVACIÓN EN TERRENO NATURAL CON EQUIPO | 19d | 2024-03-13 | 2024-03-31 | 000203 SS | 40d |  | 1.8.2.4.2.1.2 | 2097 | LACRAMARCA231001R8 | 2024-03-13 | 2024-04-22 | 2024-03-13 | 2024-04-01 | 2024-05-11 | 2024-04-01 | 204 | 204 |
| 000205 |  | RELLENO ESTRUCTURAL PARA OBRAS DE ARTE CON MATERIAL PROPIO | 19d | 2024-03-13 | 2024-03-31 | 000203 SS | 40d |  | 1.8.2.4.2.1.3 | 2098 | LACRAMARCA231001R8 | 2024-03-13 | 2024-04-22 | 2024-03-13 | 2024-04-01 | 2024-05-11 | 2024-04-01 | 205 | 205 |
|  | 2 | **OBRAS DE CONCRETO** |  | 2024-03-13 | 2024-03-31 |  |  |  |  |  |  |  |  |  |  |  |  |  |  |
| 000207 |  | ENCOFRADO Y DESENCOFRADO PARA REVESTIMIENTO DE CANALES (CERCHAS) | 19d | 2024-03-13 | 2024-03-31 | 000203 SS | 40d |  | 1.8.2.4.2.2.1 | 2100 | LACRAMARCA231001R8 | 2024-03-13 | 2024-04-22 | 2024-03-13 | 2024-04-01 | 2024-05-11 | 2024-04-01 | 207 | 207 |
| 000208 |  | ENCOFRADO Y DESENCOFRADO RECTO | 19d | 2024-03-13 | 2024-03-31 | 000203 SS | 40d |  | 1.8.2.4.2.2.2 | 2101 | LACRAMARCA231001R8 | 2024-03-13 | 2024-04-22 | 2024-03-13 | 2024-04-01 | 2024-05-11 | 2024-04-01 | 208 | 208 |
| 000209 |  | MALLA ELECTROSOLDADA DE DN6mm EN CUADRICULA 15x15 cm | 19d | 2024-03-13 | 2024-03-31 | 000203 SS | 40d |  | 1.8.2.4.2.2.3 | 2102 | LACRAMARCA231001R8 | 2024-03-13 | 2024-04-22 | 2024-03-13 | 2024-04-01 | 2024-05-11 | 2024-04-01 | 209 | 209 |
| 000210 |  | CONCRETO f'c=100 kg/cm2 | 19d | 2024-03-13 | 2024-03-31 | 000203 SS | 40d |  | 1.8.2.4.2.2.4 | 2103 | LACRAMARCA231001R8 | 2024-03-13 | 2024-04-22 | 2024-03-13 | 2024-04-01 | 2024-05-11 | 2024-04-01 | 210 | 210 |
| 000211 |  | CONCRETO f'c=280 kg/cm2 | 19d | 2024-03-13 | 2024-03-31 | 000203 SS | 40d |  | 1.8.2.4.2.2.5 | 2104 | LACRAMARCA231001R8 | 2024-03-13 | 2024-04-22 | 2024-03-13 | 2024-04-01 | 2024-05-11 | 2024-04-01 | 211 | 211 |
| 000212 |  | SELLO DE JUNTA CONSTRUCCIÓN CON MATERIAL ELASTOMÉRICO | 19d | 2024-03-13 | 2024-03-31 | 000203 SS | 40d |  | 1.8.2.4.2.2.6 | 2105 | LACRAMARCA231001R8 | 2024-03-13 | 2024-04-22 | 2024-03-13 | 2024-04-01 | 2024-05-11 | 2024-04-01 | 212 | 212 |
| 000213 |  | MAMPOSTERIA DE PIEDRA, e=20cm, ACABADO CARA VISTA | 19d | 2024-03-13 | 2024-03-31 | 000203 SS | 40d |  | 1.8.2.4.2.2.7 | 2106 | LACRAMARCA231001R8 | 2024-03-13 | 2024-04-22 | 2024-03-13 | 2024-04-01 | 2024-05-11 | 2024-04-01 | 213 | 213 |
|  | 5 | **REPOSICIÓN SIFON INOPERATIVO** |  | 2023-12-07 | 2023-12-19 |  |  |  |  |  |  |  |  |  |  |  |  |  |  |
| 000215 |  | DEMOLICIÓN DE ESTRUCTURAS EXISTENTES | 13d | 2023-12-07 | 2023-12-19 | 000051 SS+10d | 143d | 0d | 1.8.2.5.1 | 2108 | LACRAMARCA231001R8 | 2023-12-07 | 2024-04-28 | 2023-12-07 | 2023-12-20 | 2024-05-11 | 2023-12-20 | 215 | 215 |
| 000216 |  | EXCAVACIÓN ESTRUCTURAL PARA OBRAS DE ARTE | 13d | 2023-12-07 | 2023-12-19 | 000215 SS | 143d |  | 1.8.2.5.2 | 2109 | LACRAMARCA231001R8 | 2023-12-07 | 2024-04-28 | 2023-12-07 | 2023-12-20 | 2024-05-11 | 2023-12-20 | 216 | 216 |
| 000217 |  | COLOCACIÓN CAMA DE ARENA | 13d | 2023-12-07 | 2023-12-19 | 000215 SS | 143d |  | 1.8.2.5.3 | 2110 | LACRAMARCA231001R8 | 2023-12-07 | 2024-04-28 | 2023-12-07 | 2023-12-20 | 2024-05-11 | 2023-12-20 | 217 | 217 |
| 000218 |  | RELLENO ESTRUCTURAL PARA OBRAS DE ARTE CON MATERIAL PROPIO | 13d | 2023-12-07 | 2023-12-19 | 000215 SS | 143d |  | 1.8.2.5.4 | 2111 | LACRAMARCA231001R8 | 2023-12-07 | 2024-04-28 | 2023-12-07 | 2023-12-20 | 2024-05-11 | 2023-12-20 | 218 | 218 |
| 000219 |  | RELLENO COMÚN | 13d | 2023-12-07 | 2023-12-19 | 000215 SS | 143d |  | 1.8.2.5.5 | 2112 | LACRAMARCA231001R8 | 2023-12-07 | 2024-04-28 | 2023-12-07 | 2023-12-20 | 2024-05-11 | 2023-12-20 | 219 | 219 |
| 000220 |  | TUBERÍAS DE 14" HDPE SDR21 DN 355mm | 13d | 2023-12-07 | 2023-12-19 | 000215 SS | 143d |  | 1.8.2.5.6 | 2113 | LACRAMARCA231001R8 | 2023-12-07 | 2024-04-28 | 2023-12-07 | 2023-12-20 | 2024-05-11 | 2023-12-20 | 220 | 220 |
| 000221 |  | CONCRETO f'c=100 kg/cm2 | 13d | 2023-12-07 | 2023-12-19 | 000215 SS | 143d |  | 1.8.2.5.7 | 2114 | LACRAMARCA231001R8 | 2023-12-07 | 2024-04-28 | 2023-12-07 | 2023-12-20 | 2024-05-11 | 2023-12-20 | 221 | 221 |
| 000222 |  | CONCRETO f'c=280 kg/cm2 | 13d | 2023-12-07 | 2023-12-19 | 000215 SS | 143d |  | 1.8.2.5.8 | 2115 | LACRAMARCA231001R8 | 2023-12-07 | 2024-04-28 | 2023-12-07 | 2023-12-20 | 2024-05-11 | 2023-12-20 | 222 | 222 |
| 000223 |  | ENCOFRADO Y DESENCOFRADO RECTO | 13d | 2023-12-07 | 2023-12-19 | 000215 SS | 143d |  | 1.8.2.5.9 | 2116 | LACRAMARCA231001R8 | 2023-12-07 | 2024-04-28 | 2023-12-07 | 2023-12-20 | 2024-05-11 | 2023-12-20 | 223 | 223 |
| 000224 |  | ACERO DE REFUERZO fy=4200 kg/cm2 | 13d | 2023-12-07 | 2023-12-19 | 000215 SS | 143d |  | 1.8.2.5.10 | 2117 | LACRAMARCA231001R8 | 2023-12-07 | 2024-04-28 | 2023-12-07 | 2023-12-20 | 2024-05-11 | 2023-12-20 | 224 | 224 |
| 000225 |  | CODOS HDPE DE 14" DN 355mm | 13d | 2023-12-07 | 2023-12-19 | 000215 SS | 143d |  | 1.8.2.5.11 | 2118 | LACRAMARCA231001R8 | 2023-12-07 | 2024-04-28 | 2023-12-07 | 2023-12-20 | 2024-05-11 | 2023-12-20 | 225 | 225 |

| ID | WBS | Activity | Duration | Start | Finish | Predecessors | Total float | Free float | MSP Outline Number | MSP Unique ID | MSP Project Name | Imported Early Start | Imported Late Start | Imported Start | Imported Early Finish | Imported Late Finish | Imported Finish | MSP ID | MSP Task Order |
| --- | --- | --- | --- | --- | --- | --- | --- | --- | --- | --- | --- | --- | --- | --- | --- | --- | --- | --- | --- |
|  | 3 | **TRANSPORTE DE MATERIAL** |  | 2023-11-19 | 2024-05-08 |  |  |  |  |  |  |  |  |  |  |  |  |  |  |
| 000227 |  | TRANSPORTE DE MATERIAL GRANULAR PARA DISTANCIAS <1KM | 172d | 2023-11-19 | 2024-05-08 | 000023 SS | 2d | 0d | 1.8.3.1 | 2120 | LACRAMARCA231001R8 | 2023-11-19 | 2023-11-19 | 2023-11-19 | 2024-05-11 | 2024-05-11 | 2024-05-11 | 227 | 227 |
| 000228 |  | TRANSPORTE DE MATERIAL GRANULAR PARA DISTANCIAS >1KM | 172d | 2023-11-19 | 2024-05-08 | 000227 SS | 2d |  | 1.8.3.2 | 2121 | LACRAMARCA231001R8 | 2023-11-19 | 2023-11-19 | 2023-11-19 | 2024-05-11 | 2024-05-11 | 2024-05-11 | 228 | 228 |
| 000229 |  | TRANSPORTE DE ROCA PARA DISTANCIAS <1KM | 172d | 2023-11-19 | 2024-05-08 | 000227 SS | 2d |  | 1.8.3.3 | 2122 | LACRAMARCA231001R8 | 2023-11-19 | 2023-11-19 | 2023-11-19 | 2024-05-11 | 2024-05-11 | 2024-05-11 | 229 | 229 |
| 000230 |  | TRANSPORTE DE ROCA PARA DISTANCIAS >1KM | 172d | 2023-11-19 | 2024-05-08 | 000227 SS | 2d |  | 1.8.3.4 | 2123 | LACRAMARCA231001R8 | 2023-11-19 | 2023-11-19 | 2023-11-19 | 2024-05-11 | 2024-05-11 | 2024-05-11 | 230 | 230 |
| 000231 |  | TRANSPORTE DE MATERIAL EXCEDENTE PARA DISTANCIAS <1KM | 172d | 2023-11-19 | 2024-05-08 | 000227 SS | 2d |  | 1.8.3.5 | 2124 | LACRAMARCA231001R8 | 2023-11-19 | 2023-11-19 | 2023-11-19 | 2024-05-11 | 2024-05-11 | 2024-05-11 | 231 | 231 |
| 000232 |  | TRANSPORTE DE MATERIAL EXCEDENTE PARA DISTANCIAS >1KM | 172d | 2023-11-19 | 2024-05-08 | 000227 SS | 2d |  | 1.8.3.6 | 2125 | LACRAMARCA231001R8 | 2023-11-19 | 2023-11-19 | 2023-11-19 | 2024-05-11 | 2024-05-11 | 2024-05-11 | 232 | 232 |
|  | 4 | **ARQUITECTURA Y PAISAJISMO** |  | 2023-11-19 | 2023-12-06 |  |  |  |  |  |  |  |  |  |  |  |  |  |  |
|  | 1 | **OBRAS PRELIMINARES** |  | 2023-11-19 | 2023-12-06 |  |  |  |  |  |  |  |  |  |  |  |  |  |  |
| 000235 |  | MOVILIZACIÓN Y DEMOVILIZACIÓN DE EQUIPOS Y HERRAMIENTAS (ARQUITECTURA Y PAISAJISMO) | 18d | 2023-11-19 | 2023-12-06 | 000227 SS | 156d | 0d | 1.8.4.1.1 | 2128 | LACRAMARCA231001R8 | 2023-11-19 | 2024-04-23 | 2023-11-19 | 2023-12-07 | 2024-05-11 | 2023-12-07 | 235 | 235 |
| 000236 |  | TRAZO Y REPLANTEO PRELIMINAR | 18d | 2023-11-19 | 2023-12-06 | 000235 SS | 156d |  | 1.8.4.1.2 | 2129 | LACRAMARCA231001R8 | 2023-11-19 | 2024-04-23 | 2023-11-19 | 2023-12-07 | 2024-05-11 | 2023-12-07 | 236 | 236 |
|  | 2 | **MOVIMIENTO DE TIERRAS** |  | 2023-11-19 | 2023-12-06 |  |  |  |  |  |  |  |  |  |  |  |  |  |  |
| 000238 |  | EXCAVACIÓN MANUAL PARA INSTALACIÓN DE BORDILLOS Y CIMENTACIONES | 18d | 2023-11-19 | 2023-12-06 | 000235 SS | 156d |  | 1.8.4.2.1 | 2131 | LACRAMARCA231001R8 | 2023-11-19 | 2024-04-23 | 2023-11-19 | 2023-12-07 | 2024-05-11 | 2023-12-07 | 238 | 238 |
| 000239 |  | EXCAVACIÓN PARA MEJORAMIENTO DE SUELO CON TIERRA VEGETAL | 18d | 2023-11-19 | 2023-12-06 | 000235 SS | 156d |  | 1.8.4.2.2 | 2132 | LACRAMARCA231001R8 | 2023-11-19 | 2024-04-23 | 2023-11-19 | 2023-12-07 | 2024-05-11 | 2023-12-07 | 239 | 239 |
| 000240 |  | ELIMINACION DE MATERIAL EXCEDENTE (DME´S) | 18d | 2023-11-19 | 2023-12-06 | 000235 SS | 156d |  | 1.8.4.2.3 | 2133 | LACRAMARCA231001R8 | 2023-11-19 | 2024-04-23 | 2023-11-19 | 2023-12-07 | 2024-05-11 | 2023-12-07 | 240 | 240 |
|  | 3 | **PAVIMENTOS, RECUBRIMIENTOS Y BORDILLOS** |  | 2023-11-19 | 2023-12-06 |  |  |  |  |  |  |  |  |  |  |  |  |  |  |
| 000242 |  | PISO DE GRAVILLA | 18d | 2023-11-19 | 2023-12-06 | 000235 SS | 156d |  | 1.8.4.3.1 | 2135 | LACRAMARCA231001R8 | 2023-11-19 | 2024-04-23 | 2023-11-19 | 2023-12-07 | 2024-05-11 | 2023-12-07 | 242 | 242 |
| 000243 |  | RECUBRIMIENTO DE PIEDRA DEL LUGAR e=0.05cm | 18d | 2023-11-19 | 2023-12-06 | 000235 SS | 156d |  | 1.8.4.3.2 | 2136 | LACRAMARCA231001R8 | 2023-11-19 | 2024-04-23 | 2023-11-19 | 2023-12-07 | 2024-05-11 | 2023-12-07 | 243 | 243 |
| 000244 |  | BORDILLOS DE PIEDRA DEL LUGAR | 18d | 2023-11-19 | 2023-12-06 | 000235 SS | 156d |  | 1.8.4.3.3 | 2137 | LACRAMARCA231001R8 | 2023-11-19 | 2024-04-23 | 2023-11-19 | 2023-12-07 | 2024-05-11 | 2023-12-07 | 244 | 244 |
|  | 4 | **MOBILIARIOS, BARANDAS Y ESCALERAS** |  | 2023-11-19 | 2023-12-06 |  |  |  |  |  |  |  |  |  |  |  |  |  |  |
| 000246 |  | ESCALERA DE CONCRETO SOBRE ENROCADO, CIMENTACION Y ANCLAJE | 18d | 2023-11-19 | 2023-12-06 | 000235 SS | 156d |  | 1.8.4.4.1 | 2139 | LACRAMARCA231001R8 | 2023-11-19 | 2024-04-23 | 2023-11-19 | 2023-12-07 | 2024-05-11 | 2023-12-07 | 246 | 246 |
| 000247 |  | BARANDA DE MADERA EUCALIPTO CON SOGA, INCLUYE CIMENTACIÓN | 18d | 2023-11-19 | 2023-12-06 | 000235 SS | 156d |  | 1.8.4.4.2 | 2140 | LACRAMARCA231001R8 | 2023-11-19 | 2024-04-23 | 2023-11-19 | 2023-12-07 | 2024-05-11 | 2023-12-07 | 247 | 247 |
| 000248 |  | TACHOS DE BASURA, INCLUYE CIMENTACIÓN | 18d | 2023-11-19 | 2023-12-06 | 000235 SS | 156d |  | 1.8.4.4.3 | 2141 | LACRAMARCA231001R8 | 2023-11-19 | 2024-04-23 | 2023-11-19 | 2023-12-07 | 2024-05-11 | 2023-12-07 | 248 | 248 |
| 000249 |  | BANCAS DE CONCRETO, INCLUYE CIMENTACIÓN | 18d | 2023-11-19 | 2023-12-06 | 000235 SS | 156d |  | 1.8.4.4.4 | 2142 | LACRAMARCA231001R8 | 2023-11-19 | 2024-04-23 | 2023-11-19 | 2023-12-07 | 2024-05-11 | 2023-12-07 | 249 | 249 |
| 000250 |  | POSTES DE ILUMINACIÓN, INCLUYE LUMINARIA Y CIMENTACIÓN | 18d | 2023-11-19 | 2023-12-06 | 000235 SS | 156d |  | 1.8.4.4.5 | 2143 | LACRAMARCA231001R8 | 2023-11-19 | 2024-04-23 | 2023-11-19 | 2023-12-07 | 2024-05-11 | 2023-12-07 | 250 | 250 |
| 000251 |  | SEÑALETICA INFORMATIVA | 18d | 2023-11-19 | 2023-12-06 | 000235 SS | 156d |  | 1.8.4.4.6 | 2144 | LACRAMARCA231001R8 | 2023-11-19 | 2024-04-23 | 2023-11-19 | 2023-12-07 | 2024-05-11 | 2023-12-07 | 251 | 251 |
| 000252 |  | BOLARDOS DE PIEDRA | 18d | 2023-11-19 | 2023-12-06 | 000235 SS | 156d |  | 1.8.4.4.7 | 2145 | LACRAMARCA231001R8 | 2023-11-19 | 2024-04-23 | 2023-11-19 | 2023-12-07 | 2024-05-11 | 2023-12-07 | 252 | 252 |

| ID | WBS | Activity | Type | Duration | Start | Finish | Predecessors | Total float | Free float | MSP Outline Number | MSP Unique ID | MSP Project Name | Imported Early Start | Imported Late Start | Imported Start | Imported Early Finish | Imported Late Finish | Imported Finish | MSP ID | MSP Task Order |
| --- | --- | --- | --- | --- | --- | --- | --- | --- | --- | --- | --- | --- | --- | --- | --- | --- | --- | --- | --- | --- |
|  | 5 | **INSTALACION DE ALCORQUES** |  |  | 2023-11-19 | 2023-11-20 |  |  |  |  |  |  |  |  |  |  |  |  |  |  |
| 000254 |  | ALCORQUES DE PIEDRA DE CANTO RODADO PARA ARBOLES |  | 2d | 2023-11-19 | 2023-11-20 | 000235 SS | 172d |  | 1.8.4.5.1 | 2147 | LACRAMARCA231001R8 | 2023-11-19 | 2024-05-09 | 2023-11-19 | 2023-11-21 | 2024-05-11 | 2023-11-21 | 254 | 254 |
|  | 5 | **PROGRAMA DE CIERRE DE OBRA** |  |  | 2023-11-19 | 2024-05-08 |  |  |  |  |  |  |  |  |  |  |  |  |  |  |
| 000256 |  | ACONDICIONAMIENTO DE DEPOSITOS DE MATERIALES EXCEDENTES (DME) |  | 172d | 2023-11-19 | 2024-05-08 | 000023 SS | 2d | 0d | 1.8.5.1 | 2149 | LACRAMARCA231001R8 | 2023-11-19 | 2023-11-19 | 2023-11-19 | 2024-05-11 | 2024-05-11 | 2024-05-11 | 256 | 256 |
| 000257 |  | RESTAURACIÓN DE ÁREAS DE INSTALACIONES PROVISIONALES |  | 172d | 2023-11-19 | 2024-05-08 | 000256 SS | 2d |  | 1.8.5.2 | 2150 | LACRAMARCA231001R8 | 2023-11-19 | 2023-11-19 | 2023-11-19 | 2024-05-11 | 2024-05-11 | 2024-05-11 | 257 | 257 |
|  | 6 | **SEGURIDAD Y SALUD OCUPACIONAL** |  |  | 2023-11-19 | 2024-05-08 |  |  |  |  |  |  |  |  |  |  |  |  |  |  |
| 000259 |  | SEGURIDAD Y SALUD OCUPACIONAL |  | 172d | 2023-11-19 | 2024-05-08 | 000256 SS | 2d |  | 1.8.6.1 | 2152 | LACRAMARCA231001R8 | 2023-11-19 | 2023-11-19 | 2023-11-19 | 2024-05-11 | 2024-05-11 | 2024-05-11 | 259 | 259 |
| 000260 |  | IMPLEMENTACIÓN DEL PLAN PARA LA VIGILANCIA, PREVENCIÓN Y CONTROL DE COVID-19 EN EL TRABAJO |  | 172d | 2023-11-19 | 2024-05-08 | 000256 SS | 2d |  | 1.8.6.2 | 2153 | LACRAMARCA231001R8 | 2023-11-19 | 2023-11-19 | 2023-11-19 | 2024-05-11 | 2024-05-11 | 2024-05-11 | 260 | 260 |
|  | 7 | **LIMPIEZA Y ENTREGA** |  |  | 2024-05-01 | 2024-05-10 |  |  |  |  |  |  |  |  |  |  |  |  |  |  |
| 000263 |  | LIMPIEZA DEL SITIO |  | 10d | 2024-05-01 | 2024-05-10 | 000262 FS-10d | 0d |  | 1.9.2 | 2157 | LACRAMARCA231001R8 | 2024-05-01 | 2024-05-01 | 2024-05-01 | 2024-05-11 | 2024-05-11 | 2024-05-11 | 263 | 263 |
| 000262 |  | TERMINO DE LOS TRABAJOS | milestone | 0d | 2024-05-10 | 2024-05-10 | 000256, 000227, 000014, 000075, 000072, 000017 | 0d |  | 1.9.1 | 2156 | LACRAMARCA231001R8 | 2024-05-12 | 2024-05-11 | 2024-05-11 | 2024-05-11 | 2024-05-11 | 2024-05-11 | 262 | 262 |
| 000264 |  | ENTREGA | milestone | 0d | 2024-05-10 | 2024-05-10 | 000263 | 0d |  | 1.9.3 | 2158 | LACRAMARCA231001R8 | 2024-05-12 | 2024-05-11 | 2024-05-11 | 2024-05-11 | 2024-05-11 | 2024-05-11 | 264 | 264 |
